# MINUS_Schedule_2008_1015

Schedule from MS Project, 2008-09-04 to 2008-12-01, A marks actual dates.
Booz Allen Hamilton

## Calendars

- Standard: Mon-Fri 08:00-12:00, 13:00-17:00; Sat-Sun off.

## Schedule

| ID | WBS | Task | Type | Duration | Start | Finish | Predecessors | Complete | Remaining | Total slack | Free slack | Constraint |
| --- | --- | --- | --- | --- | --- | --- | --- | --- | --- | --- | --- | --- |
| 1 | 1 | **MINUS Research Schedule** |  | 63d? | 2008-09-04 A | 2008-12-01 |  |  | 62.88d? | 0d |  |  |
| 2 | 1.1 | **Prepare Proposal** |  | 6d | 2008-09-04 A | 2008-09-11 |  | 2% | 5.87d | 0d |  |  |
| 3 | 1.1.1 | Develop Project Scope |  | 5d | 2008-09-04 A | 2008-09-10 |  | 3% | 4.87d | 0d |  | start no earlier than 2008-02-25 |
| 4 | 1.1.2 | Identify Stakeholders |  | 1.13d | 2008-09-04 A | 2008-09-11 | 3 | 12% | 1d | 0d |  | finish no earlier than 2008-09-11 |
| 5 | 1.1.3 | Conduct Market Research |  | 6d | 2008-09-04 A | 2008-09-11 | 4 |  | 6d | 0d |  | finish no earlier than 2008-09-11 |
| 6 | 1.2 | **Concept Development** |  | 18d | 2008-09-12 | 2008-10-07 | 5 |  |  | 39d |  |  |
| 7 | 1.2.1 | Draft System level CONOPS |  | 10d | 2008-09-12 | 2008-09-25 | 2 |  |  | 39d | 0d |  |
| 8 | 1.2.2 | Finalize CONOPS | milestone | 8d | 2008-09-26 | 2008-10-07 | 7 |  |  | 39d |  |  |
| 9 | 1.3 | **Requirements Specification** |  | 34d | 2008-09-12 | 2008-10-29 | 2 |  |  | 0d |  |  |
| 10 | 1.3.1 | Define Problem |  | 2d | 2008-09-12 | 2008-09-15 | 2 |  |  | 0d |  |  |
| 11 | 1.3.2 | Identify Detailed System Objectives |  | 5d | 2008-09-16 | 2008-09-22 | 10 |  |  | 0d |  |  |
| 12 | 1.3.3 | Define Functions and Behavior of the System |  | 5d | 2008-09-23 | 2008-09-29 | 11 |  |  | 0d |  |  |
| 13 | 1.3.4 | Document System Capabilities and Requirements |  | 17d | 2008-09-30 | 2008-10-22 | 12 |  |  | 23d | 0d |  |
| 14 | 1.3.5 | Finalize ICD/Requirements Document | milestone | 5d | 2008-10-23 | 2008-10-29 | 13 |  |  | 23d |  |  |
| 15 | 1.4 | **Preliminary Design** |  | 34d | 2008-09-30 | 2008-11-14 | 12 |  |  | 0d |  |  |
| 16 | 1.4.1 | Develop Use Cases |  | 3d | 2008-09-30 | 2008-10-02 | 12 |  |  | 0d |  |  |
| 17 | 1.4.2 | Identify Hardware/Software Alternatives |  | 8d | 2008-10-03 | 2008-10-14 | 16 |  |  | 0d |  |  |
| 18 | 1.4.3 | Cost Analysis |  | 5d | 2008-10-15 | 2008-10-21 | 17 |  |  | 0d |  |  |
| 19 | 1.4.4 | Determine Hardware/Software Components |  | 4d | 2008-10-22 | 2008-10-27 | 18 |  |  | 0d |  |  |
| 20 | 1.4.5 | Document Preliminary Design | milestone | 14d | 2008-10-28 | 2008-11-14 | 19 |  |  | 11d |  |  |
| 21 | 1.5 | **Architecture Development** |  | 15d? | 2008-10-28 | 2008-11-17 | 19 |  |  | 10d |  |  |
| 22 | 1.5.1 | Develop Operational View (OV-1: High Level Operational Concept Graphic) |  | 4d | 2008-10-28 | 2008-10-31 | 19 |  |  | 10d | 0d |  |
| 23 | 1.5.2 | Develop Technical View (TV-1: Technical Architecture Profile) |  | 5d | 2008-11-03 | 2008-11-07 | 22 |  |  | 10d | 0d |  |
| 24 | 1.5.3 | Develop Systems View (SV-1: System Interface Description) |  | 5d | 2008-11-10 | 2008-11-14 | 23 |  |  | 10d | 0d |  |
| 25 | 1.5.4 | Finalize Architecture Views | milestone | 1d? | 2008-11-17 | 2008-11-17 | 24 |  |  | 10d |  |  |

| ID | WBS | Task | Type | Duration | Start | Finish | Predecessors | Total slack |
| --- | --- | --- | --- | --- | --- | --- | --- | --- |
| 26 | 1.6 | **Business Case Development** |  | 19d | 2008-10-28 | 2008-11-21 | 19 | 0d |
| 27 | 1.6.1 | Conduct Sensitivity Analysis |  | 4d | 2008-10-28 | 2008-10-31 | 19 | 0d |
| 28 | 1.6.2 | Conduct Risk Analysis |  | 4d | 2008-11-03 | 2008-11-06 | 27 | 0d |
| 29 | 1.6.3 | Develop Marketing Strategy |  | 4d | 2008-11-07 | 2008-11-12 | 28 | 0d |
| 30 | 1.6.4 | Finalize Business Case | milestone | 7d | 2008-11-13 | 2008-11-21 | 29 | 0d |
| 31 | 1.7 | **Project Report** |  | 6d | 2008-11-24 | 2008-12-01 | 30 | 0d |
| 32 | 1.7.1 | Consolidate deliverables into a single report |  | 1d | 2008-11-24 | 2008-11-24 | 30 | 0d |
| 33 | 1.7.2 | Finalize Report | milestone | 5d | 2008-11-25 | 2008-12-01 | 32 | 0d |
